# Planning de réalisation

Schedule from MS Project, 2018-01-10 to 2018-06-25, 7 hours a day, costs in €.

## Calendars

- Standard: Mon-Fri 09:00-12:00, 14:00-18:00; Sat-Sun off. Exceptions (off unless hours are given): 2018-04-02 (Pâques), 2018-05-01 (Fëte du travail), 2018-05-10 (Ascension), 2018-05-21 (Lundi de Pentecôte).

## Resources

| Resource | Rate |
| --- | --- |
| ATTOUCHI Billel | 18.02 |
| DE CARVALHO Steven | 22.55 |
| Ordinateur | 900 |
| Hébergement OVH | 0.04 |
| SSL E-commerce | 0.71 |
| Nicolas UX / UI | 13.26 |
| Thème Avada | 50.76 |
| Plugin WPForms Pro | 0.09 |

## Schedule

| ID | WBS | Task | Duration | Start | Finish | Predecessors | Total slack | Free slack | Resources | Work | Cost |
| --- | --- | --- | --- | --- | --- | --- | --- | --- | --- | --- | --- |
| 1 | 1 | **PharmaLiv** | 114.5d | 2018-01-10 | 2018-06-25 |  | 0d |  | Ordinateur [200%] | 3244.5h | 31,983.47 |
| 2 | 1.1 | **Initialisation du projet** | 23d | 2018-01-10 | 2018-02-09 |  | 0d |  |  | 322h | 6,531.31 |
| 3 | 1.1.1 | Etude de la demande | 2d | 2018-01-10 | 2018-01-11 |  | 0d |  | DE CARVALHO Steven | 14h | 315.7 |
| 4 | 1.1.2 | Analyse de la concurrence | 0.5d | 2018-01-10 | 2018-01-10 |  | 0d |  | ATTOUCHI Billel | 3.5h | 63.06 |
| 5 | 1.1.3 | Interview | 1.5d | 2018-01-10 | 2018-01-11 | 4 | 0d |  | ATTOUCHI Billel | 10.5h | 189.18 |
| 6 | 1.1.4 | Rédaction du cahier des charges | 20d | 2018-01-12 | 2018-02-08 | 3, 5 | 0d |  | ATTOUCHI Billel; DE CARVALHO Steven | 280h | 5,679.4 |
| 7 | 1.1.5 | Qualification | 1d | 2018-02-09 | 2018-02-09 | 6 | 0d |  | ATTOUCHI Billel; DE CARVALHO Steven | 14h | 283.97 |
| 8 | 1.2 | **Plannification** | 7.5d | 2018-02-12 | 2018-02-21 |  | 0d |  |  | 115.5h | 2,152.36 |
| 9 | 1.2.1 | GANTT / WBS | 1d | 2018-02-12 | 2018-02-12 | 7 | 0d |  | DE CARVALHO Steven | 7h | 157.85 |
| 10 | 1.2.2 | Arborescence complète | 0.5d | 2018-02-13 | 2018-02-13 | 9 | 0d |  | DE CARVALHO Steven | 3.5h | 78.93 |
| 11 | 1.2.3 | Wireframes & maquettages | 5d | 2018-02-13 | 2018-02-20 | 10 | 0d |  | Nicolas UX / UI | 35h | 464 |
| 12 | 1.2.4 | Modèle Conceptuel des Données (MCD) | 2d | 2018-02-13 | 2018-02-15 | 10 | 0d |  | ATTOUCHI Billel; DE CARVALHO Steven | 28h | 567.94 |
| 13 | 1.2.5 | Modèle Logique des Données (MLD) | 1d | 2018-02-15 | 2018-02-16 | 12 | 2d |  | ATTOUCHI Billel | 7h | 126.12 |
| 14 | 1.2.6 | Charte graphique | 3d | 2018-02-15 | 2018-02-20 | 12 | 0d |  | DE CARVALHO Steven | 21h | 473.55 |
| 15 | 1.2.7 | Proposition au client | 1d | 2018-02-20 | 2018-02-21 | 11, 13, 14 | 0d |  | ATTOUCHI Billel; DE CARVALHO Steven | 14h | 283.97 |
| 16 | 1.3 | **Réalisation** | 77d | 2018-02-21 | 2018-06-14 |  | 0d |  | Hébergement OVH; Plugin WPForms Pro; SSL E-commerce | 2583h | 19,912.21 |
| 17 | 1.3.1 | Prise en main logiciel | 1d | 2018-02-21 | 2018-02-22 | 15 | 0d |  | ATTOUCHI Billel; DE CARVALHO Steven | 14h | 283.97 |
| 18 | 1.3.2 | Installation Réseau et Base de données | 3d | 2018-02-22 | 2018-02-27 | 17 | 0d |  | ATTOUCHI Billel; DE CARVALHO Steven | 42h | 851.91 |
| 19 | 1.3.3 | Préparation fonctionnelle | 3d | 2018-02-27 | 2018-03-02 | 18 | 0d |  | ATTOUCHI Billel; DE CARVALHO Steven | 42h | 851.91 |
| 20 | 1.3.4 | **Site vitrine** | 46d | 2018-03-02 | 2018-05-09 |  | 17.5d |  |  | 322h | 7,311.93 |
| 21 | 1.3.4.1 | Installation WordPress + Plugins | 1d | 2018-03-02 | 2018-03-05 | 19 | 17.5d | 0d | DE CARVALHO Steven; Thème Avada | 7h | 208.61 |
| 22 | 1.3.4.2 | Codage | 40d | 2018-03-05 | 2018-05-02 | 21 | 17.5d | 0d | DE CARVALHO Steven | 280h | 6,314.06 |
| 23 | 1.3.4.3 | Intégration | 5d | 2018-05-02 | 2018-05-09 | 22 | 17.5d |  | DE CARVALHO Steven | 35h | 789.26 |
| 24 | 1.3.5 | **Application PharmaLiv** | 63.5d | 2018-03-02 | 2018-06-05 |  | 0d |  |  | 469h | 8,561 |
| 25 | 1.3.5.1 | Codage | 60d | 2018-03-02 | 2018-05-31 | 19 | 0d |  | ATTOUCHI Billel | 420h | 7,567.11 |
| 26 | 1.3.5.2 | Intégration | 3.5d | 2018-05-31 | 2018-06-05 | 25 | 0d |  | ATTOUCHI Billel; DE CARVALHO Steven | 49h | 993.89 |
| 27 | 1.3.6 | Dépôt de nom + SSL + HTTPS | 2d | 2018-06-06 | 2018-06-07 | 23, 26 | 0d |  | DE CARVALHO Steven | 14h | 315.7 |
| 28 | 1.3.7 | Phases de tests | 4d | 2018-06-08 | 2018-06-13 | 27 | 0d |  | ATTOUCHI Billel; DE CARVALHO Steven | 56h | 1,135.88 |
| 29 | 1.3.8 | Mise en service | 0.5d | 2018-06-14 | 2018-06-14 | 28 | 0d |  | ATTOUCHI Billel; DE CARVALHO Steven | 7h | 141.99 |

| ID | WBS | Task | Type | Duration | Start | Finish | Predecessors | Total slack | Resources | Work | Cost |
| --- | --- | --- | --- | --- | --- | --- | --- | --- | --- | --- | --- |
| 30 | 1.4 | **Clôture et Recettage** |  | 7d | 2018-06-14 | 2018-06-25 |  | 0d | Hébergement OVH; Plugin WPForms Pro; SSL E-commerce | 224h | 1,587.6 |
| 31 | 1.4.1 | Recettage |  | 1d | 2018-06-14 | 2018-06-15 | 29 | 2d | DE CARVALHO Steven | 7h | 157.85 |
| 32 | 1.4.2 | Formations |  | 3d | 2018-06-14 | 2018-06-19 | 29 | 0d | ATTOUCHI Billel | 21h | 378.36 |
| 33 | 1.4.3 | Etudes des données de clôture |  | 1d | 2018-06-19 | 2018-06-20 | 31, 32 | 0d | DE CARVALHO Steven | 7h | 157.85 |
| 34 | 1.4.4 | Retour d'expérience (REX) |  | 3d | 2018-06-20 | 2018-06-25 | 33 | 0d | DE CARVALHO Steven; ATTOUCHI Billel | 42h | 851.91 |
| 35 | 1.4.5 | Point de clôture | milestone | 0d | 2018-06-25 | 2018-06-25 | 34 | 0d |  |  |  |
